# VOORBEREIDING AANLOOPFASE

Schedule from MS Project, 2003-01-12 to 2003-03-07, status date 2003-01-08.
BAM Nelissen Van Egteren

## Calendars

- ALLEEN WERKDAGEN: Mon-Fri 08:30-12:30, 13:00-17:00; Sat-Sun off. Exceptions (off unless hours are given): 2003-01-11 to 2003-01-12 08:30-12:30, 13:00-17:00, 2003-01-18 to 2003-01-19 08:30-12:30, 13:00-17:00, 2003-01-25 to 2003-01-26 08:30-12:30, 13:00-17:00, 2003-02-01 to 2003-02-02 08:30-12:30, 13:00-17:00, 2003-02-08 to 2003-02-09 08:30-12:30, 13:00-17:00, 2003-02-15 to 2003-02-16 08:30-12:30, 13:00-17:00, 2003-02-22 to 2003-02-23 08:30-12:30, 13:00-17:00, 2003-03-01 to 2003-03-02 08:30-12:30, 13:00-17:00.

## Schedule

| ID | WBS | Task | Type | Duration | Start | Finish | Predecessors | Total slack | Free slack |
| --- | --- | --- | --- | --- | --- | --- | --- | --- | --- |
| 1 | 1 | **GRONDWERK** |  | 34d | 2003-01-12 | 2003-02-14 |  | 21d |  |
| 2 | 1.1 | bouwopdracht | milestone | 0d | 2003-01-12 | 2003-01-12 |  | 25d | 0d |
| 3 | 1.2 | prijsaanvraag grondwerk opstellen |  | 2d | 2003-01-12 | 2003-01-13 | 2 | 21d | 0d |
| 4 | 1.3 | offertes aanvragen grondboeren |  | 3d | 2003-01-14 | 2003-01-16 | 3 | 21d | 0d |
| 5 | 1.4 | o.a. prijsaanbieding maken |  | 7d | 2003-01-17 | 2003-01-23 | 4SS+3d | 21d | 0d |
| 6 | 1.5 | offertes grondboeren beoordelen |  | 3d | 2003-01-24 | 2003-01-26 | 5SS+4d | 21d | 0d |
| 7 | 1.6 | prijsonderhandeling met o.a. |  | 5d | 2003-01-27 | 2003-01-31 | 6SS+3d | 21d | 0d |
| 8 | 1.7 | onderaann.contract opstellen |  | 3d | 2003-02-01 | 2003-02-03 | 7SS+3d | 21d | 0d |
| 9 | 1.8 | opdracht aan grondbedrijf |  | 1d | 2003-02-04 | 2003-02-04 | 8 | 21d | 0d |
| 10 | 1.9 | afstemming werkzaamheden |  | 10d | 2003-02-05 | 2003-02-14 | 9 | 21d | 0d |
| 11 | 1.10 | start grondwerk | milestone | 0d | 2003-02-14 | 2003-02-14 | 10 | 21d |  |
| 13 | 2 | **BRONBEMALING** |  | 35d | 2003-01-12 | 2003-02-15 |  | 20d |  |
| 14 | 2.1 | bouwopdracht | milestone | 0d | 2003-01-12 | 2003-01-12 |  | 20d | 0d |
| 15 | 2.2 | prijsaanvraag bemaling opstellen |  | 3d | 2003-01-12 | 2003-01-14 | 14 | 20d | 0d |
| 16 | 2.3 | offertes bemaling aanvragen |  | 3d | 2003-01-15 | 2003-01-17 | 15 | 20d | 0d |
| 17 | 2.4 | o.a. prijsaanbieding maken |  | 7d | 2003-01-18 | 2003-01-24 | 16 | 20d | 0d |
| 18 | 2.5 | offertes bemaling beoordelen |  | 3d | 2003-01-25 | 2003-01-27 | 17 | 20d | 0d |
| 19 | 2.6 | prijsonderhandeling met onderaann.. |  | 5d | 2003-01-28 | 2003-02-01 | 18 | 20d | 0d |
| 20 | 2.7 | onderaann.contract opstellen |  | 3d | 2003-02-02 | 2003-02-04 | 19 | 20d | 0d |
| 21 | 2.8 | opdracht aan bemalingsbedrijf |  | 1d | 2003-02-05 | 2003-02-05 | 20 | 20d | 0d |
| 22 | 2.9 | afstemming werkzaamheden |  | 10d | 2003-02-06 | 2003-02-15 | 21 | 20d | 0d |
| 23 | 2.10 | start bronbemaling | milestone | 0d | 2003-02-15 | 2003-02-15 | 22 | 20d |  |
| 25 | 3 | **PAALFUNDATIE prefab palen** |  | 55d | 2003-01-12 | 2003-03-07 |  | 0d |  |
| 26 | 3.1 | bouwopdracht | milestone | 0d | 2003-01-12 | 2003-01-12 |  | 55d |  |

| ID | WBS | Task | Type | Duration | Start | Finish | Predecessors | Total slack | Free slack |
| --- | --- | --- | --- | --- | --- | --- | --- | --- | --- |
| 27 | 3.2 | **palenplan maken** |  | 25d | 2003-01-12 | 2003-02-05 |  | 0d |  |
| 28 | 3.2.1 | gewichtsberekeningen |  | 5d | 2003-01-12 | 2003-01-16 |  | 50d |  |
| 29 | 3.2.2 | sonderingen bouwplaats |  | 5d | 2003-01-12 | 2003-01-16 |  | 0d |  |
| 30 | 3.2.3 | palenplan tekenen |  | 10d | 2003-01-17 | 2003-01-26 | 29 | 0d |  |
| 31 | 3.2.4 | palenplan controleren |  | 5d | 2003-01-27 | 2003-01-31 | 30 | 30d | 0d |
| 32 | 3.2.5 | palenplan definitief |  | 5d | 2003-02-01 | 2003-02-05 | 31 | 30d |  |
| 33 | 3.3 | **levering betonpalen** |  | 40d | 2003-01-27 | 2003-03-07 |  | 0d |  |
| 34 | 3.3.1 | prijsaanvraag palen opstellen |  | 3d | 2003-01-27 | 2003-01-29 | 30 | 0d |  |
| 35 | 3.3.2 | offertes palen aanvragen |  | 3d | 2003-01-30 | 2003-02-01 | 34 | 0d |  |
| 36 | 3.3.3 | lev. prijsaanbieding maken |  | 7d | 2003-02-02 | 2003-02-08 | 35 | 0d |  |
| 37 | 3.3.4 | offertes palen beoordelen |  | 3d | 2003-02-09 | 2003-02-11 | 36 | 0d |  |
| 38 | 3.3.5 | prijsonderhandeling met leveranc |  | 5d | 2003-02-12 | 2003-02-16 | 37 | 0d |  |
| 39 | 3.3.6 | leveringscontract opstellen |  | 3d | 2003-02-17 | 2003-02-19 | 38 | 0d |  |
| 40 | 3.3.7 | opdracht palen leverancier |  | 1d | 2003-02-20 | 2003-02-20 | 39 | 0d |  |
| 41 | 3.3.8 | productietijd prefab palen |  | 15d | 2003-02-21 | 2003-03-07 | 40 | 0d |  |
| 42 | 3.3.9 | start paalfundatie | milestone | 0d | 2003-03-07 | 2003-03-07 | 41 | 0d |  |
| 43 | 3.4 | **heibedrijf** |  | 35d | 2003-01-27 | 2003-03-02 |  | 5d |  |
| 44 | 3.4.1 | prijsaanvraag heiwerk opstellen |  | 3d | 2003-01-27 | 2003-01-29 | 30 | 5d | 0d |
| 45 | 3.4.2 | offertes heiwerk aanvragen |  | 3d | 2003-01-30 | 2003-02-01 | 44 | 5d | 0d |
| 46 | 3.4.3 | o.a. prijsaanbieding maken |  | 7d | 2003-02-02 | 2003-02-08 | 45 | 5d | 0d |
| 47 | 3.4.4 | offertes heiwerk beoordelen |  | 3d | 2003-02-09 | 2003-02-11 | 46 | 5d | 0d |
| 48 | 3.4.5 | prijsonderhandeling met heibedrijf |  | 5d | 2003-02-12 | 2003-02-16 | 47 | 5d | 0d |
| 49 | 3.4.6 | onderaann.contract opstellen |  | 3d | 2003-02-17 | 2003-02-19 | 48 | 5d | 0d |
| 50 | 3.4.7 | opdracht aan heibedrijf |  | 1d | 2003-02-20 | 2003-02-20 | 49 | 5d | 0d |
| 51 | 3.4.8 | afstemming werkzaamheden |  | 10d | 2003-02-21 | 2003-03-02 | 50 | 5d | 0d |
| 52 | 3.4.9 | start paalfundatie | milestone | 0d | 2003-03-02 | 2003-03-02 | 51 | 5d |  |
